# MAPS Inner Barrel

Schedule from MS Project, 2016-10-03 to 2022-12-29, costs in $, A marks actual dates.
LANL

## Calendars

- Standard: Mon-Fri 08:00-12:00, 13:00-17:00; Sat-Sun off. Exceptions (off unless hours are given): 2017-01-02, 2017-02-20, 2017-05-29, 2017-07-04, 2017-09-04, 2017-10-09, 2017-11-10, 2017-11-23 to 2017-11-24, 2017-12-25 to 2017-12-29.

## Resources

| Resource | Rate | Cost per use |
| --- | --- | --- |
| Mech Liason Eng | 130 |  |
| Elec Liason Eng | 130 |  |
| Project Manager | 130 |  |
| Physicist |  |  |
| Elec tech | 97 |  |
| Mech Tech | 97 |  |
| Electronics Engineer | 130 |  |
| Mechanical Engineer | 130 |  |
| M&S |  | 1 |
| Electrical Engineer | 130 |  |
| LDRD Physicist | 230 |  |
| LDRD PostDoc | 90 |  |
| LDRD Electronics Engineer | 230 |  |
| LDRD Mechnical Engineer | 230 |  |
| LDRD Mechnical Tech | 150 |  |
| LDRD Electronics Tech | 150 |  |
| PROF4_institution_LANL | 133.9 |  |
| SCI3_Institution_LANL |  |  |
| TECH4_Institution_LANL | 154.5 |  |
| PROF4_Institution_MIT | 159 |  |
| SCI3_Institution_MIT |  |  |
| TECH4_Institution_MIT | 93 |  |
| MECHTECH4_Institution_LBNL | 120.49 |  |
| STAFFPHYS_Institution_LBNL |  |  |
| ELENG3_Institution_LBNL | 164.97 |  |
| MECHENG3_Institution_LBNL | 136.14 |  |
| ELTECH4_Institution_LBNL | 99.02 |  |
| POSTD_Institution_LBNL |  |  |
| MACH4_Institution_LBNL | 129.49 |  |
| CMMTECH4_Institution_LBNL | 113.13 |  |
| MECHENG4_Institution_LBNL | 198.88 |  |
| GRSTUD_Institution_LBNL |  |  |
| MGR_Institution_LANL | 236.9 |  |
| b |  |  |
| ElectTech_Institution_UTAustin | 90 |  |

## Schedule

| ID | WBS | Task | Type | Duration | Start | Finish | Predecessors | Remaining | Baseline start | Baseline finish | Baseline duration | Total slack | Free slack | Constraint | Work | Actual work | Cost | Actual cost | Activity |
| --- | --- | --- | --- | --- | --- | --- | --- | --- | --- | --- | --- | --- | --- | --- | --- | --- | --- | --- | --- |
| 1 | 1 | **MVTX Inner Barrel** |  | 1282d | 2016-10-03 A | 2021-09-20 |  | 1279.76d |  |  |  |  |  | start no earlier than 2005-10-21 | 49766.5h | 40h | 9,288,960.19 | 10,328 |  |
| 2 | 1.1 | **ALICE ITS Key Tasks** |  | 413d | 2016-11-28 | 2018-07-17 |  |  | 2016-11-28 | 2018-07-17 | 413d |  |  |  |  |  |  |  |  |
| 3 | 1.1.1 | ALICE MAPS Production | manual | 240d | 2016-11-28 | 2017-11-06 |  |  | 2016-11-28 | 2017-11-06 | 240d |  |  | start no earlier than 2016-11-28 |  |  |  |  |  |
| 4 | 1.1.2 | ALICE ITS IB FPC Production | manual | 200d | 2017-06-01 | 2018-03-22 |  |  | 2017-02-23 | 2017-09-01 | 135d |  |  | start no earlier than 2017-06-01 |  |  |  |  |  |
| 5 | 1.1.3 | ALICE ITS IB Stave frame Production | manual | 240d | 2017-04-20 | 2018-04-06 | 4SS+2mo |  | 2017-04-20 | 2018-04-06 | 240d |  |  | finish no earlier than 2018-01-02 |  |  |  |  |  |
| 6 | 1.1.4 | ALICE ITS IB Stave Assembly | manual | 300d | 2017-06-16 | 2018-08-24 | 5SS+2mo |  | 2017-06-16 | 2018-09-01 | 306d |  |  | start no earlier than 2017-06-19 |  |  |  |  | ITS construction |
| 7 | 1.1.5 | ALICE ITS Electronics Pre-Production | manual | 100d | 2018-01-01 | 2018-05-18 |  |  | 2017-03-13 | 2017-08-01 | 100d |  |  | start no earlier than 2018-01-01 |  |  |  |  | ITS Electronics Pre-Production |
| 8 | 1.1.6 | ALICE ITS Electronics Production | manual | 240d | 2018-02-01 | 2019-01-02 | 7 |  | 2017-08-02 | 2018-07-17 | 240d |  |  | start no earlier than 2018-02-01 |  |  |  |  | ITS Electronics Production |
| 9 | 1.2 | **sPHENIX Milestones** |  | 1181d | 2016-11-01 | 2021-06-01 |  |  | 2016-11-01 | 2021-06-01 | 1181d |  |  |  |  |  |  |  |  |
| 10 | 1.2.1 | sPHENIX CD-1 Review | milestone | 0d | 2017-05-08 | 2017-05-08 |  |  | 2016-11-01 | 2016-11-01 | 0d | 1462d |  | start no earlier than 2017-05-08 |  |  |  |  |  |
| 11 | 1.2.2 | sPHENIX Construction starts | milestone | 0d | 2018-10-01 | 2018-10-01 |  |  | 2017-11-01 | 2017-11-01 | 0d | 1109d |  | start no earlier than 2018-10-01 |  |  |  |  |  |
| 12 | 1.2.3 | sPHENIX Installation Starts | milestone | 0d | 2021-04-01 | 2021-04-01 |  |  | 2021-04-01 | 2021-04-01 | 0d | 456d |  | start no earlier than 2021-04-01 |  |  |  |  |  |
| 13 | 1.2.4 | INTT Ready for Installation | milestone | 0d | 2022-04-01 | 2022-04-01 |  |  | 2022-04-01 | 2022-04-01 | 0d | -268d | 0d | start no earlier than 2022-04-01 |  |  |  |  |  |
| 14 | 1.2.5 | MVTX Ready for Installation | milestone | 0d | 2022-04-01 | 2022-04-01 | 13 |  |  |  |  | -268d | 0d |  |  |  |  |  |  |
| 15 | 1.2.6 | sPHENIX Installed and Ready for Beam | milestone | 0d | 2022-07-01 | 2022-07-01 | 14 |  | 2022-07-01 | 2022-07-01 | 0d | -333d | 0d | start no earlier than 2022-07-01 |  |  |  |  | ready for beam (6/2021) |
| 16 | 1.3 | **LDRD Milestones & Critical Tasks** |  | 781d | 2016-10-03 | 2019-10-18 |  |  | 2016-10-03 | 2019-10-18 | 781d |  |  |  |  |  |  |  |  |
| 17 | 1.3.1 | LDRD Start and End |  | 767d | 2016-10-03 | 2019-09-30 |  |  | 2016-10-03 | 2019-10-18 | 781d | 848d |  | start no earlier than 2016-10-03 |  |  |  |  |  |
| 18 | 1.3.2 | Complete MoU LANL-ALICE | milestone | 0d | 2016-10-03 | 2016-10-03 |  |  | 2016-12-09 | 2016-12-09 | 0d | 781d |  |  |  |  |  |  |  |
| 19 | 1.3.3 | Setup ALICE Readout Test Stands | milestone | 0d | 2016-10-03 | 2016-10-03 |  |  | 2017-09-22 | 2017-09-22 | 0d | 781d |  |  |  |  |  |  |  |
| 20 | 1.3.4 | Pixel Chip HS Readout | milestone | 0d | 2017-03-15 | 2017-03-15 |  |  | 2017-03-15 | 2017-03-15 | 0d | 1500d |  | start no earlier than 2017-03-15 |  |  |  |  |  |
| 21 | 1.3.5 | ATLAS FELIX v1.5 Delivery | milestone | 0d | 2017-05-01 | 2017-05-01 |  |  | 2017-05-01 | 2017-05-01 | 0d | 1467d |  | start no earlier than 2017-05-01 |  |  |  |  |  |
| 22 | 1.3.6 | ALICE RU v1.0 Delivery | milestone | 0d | 2017-10-30 | 2017-10-30 |  |  | 2017-05-30 | 2017-05-30 | 0d | 1341d |  | start no earlier than 2017-10-30 |  |  |  |  |  |
| 23 | 1.3.7 | ALICE Final RU Delivery | milestone | 0d | 2018-03-01 | 2018-03-01 |  |  |  |  |  | 1261d |  | start no earlier than 2018-03-01 |  |  |  |  |  |
| 24 | 1.3.8 | ATLS FELIX v2.0 Delivery | milestone | 0d | 2018-02-28 | 2018-02-28 |  |  | 2018-01-02 | 2018-01-02 | 0d | 1262d |  | start no earlier than 2018-02-28 |  |  |  |  |  |
| 25 | 1.3.9 | Prototype Stave | milestone | 0d | 2018-03-30 | 2018-03-30 |  |  | 2017-09-11 | 2017-09-11 | 0d | 1240d |  | start no earlier than 2018-03-30 |  |  |  |  |  |

Notes:
- 11: critical and lond lead time items can be purchased at CD3a
- 13: constructino fund available at CD-3b
- 15: commissioning 4/1-6/1, 2021; / ready for beam 6/1/2021
- 20: LDRD complete full readout electronics final design

| ID | WBS | Task | Type | Duration | Start | Finish | Predecessors | Complete | Remaining | Baseline start | Baseline finish | Baseline duration | Total slack | Free slack | Constraint | Resources | Work | Actual work | Cost | Baseline cost | Actual cost | Activity | Institution |
| --- | --- | --- | --- | --- | --- | --- | --- | --- | --- | --- | --- | --- | --- | --- | --- | --- | --- | --- | --- | --- | --- | --- | --- |
| 26 | 1.4 | **LANL LDRD** |  | 1174d | 2016-10-03 A | 2021-04-21 |  |  | 1168.3d |  |  |  |  |  |  |  | 22368.5h | 40h | 4,551,300 |  | 10,328 | LANL R&D |  |
| 27 | 1.4.1 | MOU btw LANL and ALICE for R&D |  | 50d | 2016-10-03 | 2016-12-09 |  |  |  | 2016-10-03 | 2016-12-09 | 50d | 768d | 123d | start no earlier than 2016-10-03 | LDRD Physicist [20%] | 80h |  | 18,400 | 18,400 |  |  | LDRD |
| 28 | 1.4.2 | Requirements/Specifications |  | 25d | 2017-05-01 | 2017-06-05 |  |  |  | 2017-05-01 | 2017-06-05 | 25d | 463d | 0d | start no earlier than 2017-05-01 |  |  |  |  |  |  |  |  |
| 29 | 1.4.3 | **Obtain Designs from ALICE** |  | 30d | 2016-12-12 | 2017-01-23 |  |  |  | 2016-12-12 | 2017-01-23 | 30d | -192d | 0d |  |  | 720h |  | 82,800 | 82,800 |  |  |  |
| 30 | 1.4.3.1 | Obtain Test Stand Design from CERN | milestone | 30d | 2016-12-12 | 2017-01-23 |  |  |  | 2016-12-12 | 2017-01-23 | 30d | 1094d |  | start no earlier than 2016-12-12 | LDRD Electronics Engineer [50%]; Physicist [50%] | 240h |  | 27,600 | 27,600 |  |  | LDRD |
| 31 | 1.4.3.2 | Obtain ALICE Readout Unit Design | milestone | 30d | 2016-12-12 | 2017-01-23 |  |  |  | 2016-12-12 | 2017-01-23 | 30d | 1094d |  | start no earlier than 2016-12-12 | Physicist [50%]; LDRD Electronics Engineer [50%] | 240h |  | 27,600 | 27,600 |  |  | LDRD |
| 32 | 1.4.3.3 | Obtain ALICE CAD model | milestone | 30d | 2016-12-12 | 2017-01-23 |  |  |  | 2016-12-12 | 2017-01-23 | 30d | -192d | 0d | start no earlier than 2016-12-12 | Physicist [50%]; LDRD Mechnical Engineer [50%] | 240h |  | 27,600 | 27,600 |  | ALICE CAD model | LDRD |
| 33 | 1.4.4 | **Setup Alice Readout Test Stand** |  | 200d | 2016-12-12 A | 2017-09-22 |  | 14% | 171d | 2016-12-12 | 2017-09-22 | 200d | 864d | 0d |  |  | 372h | 40h | 94,548 | 94,548 | 10,328 |  | LDRD |
| 34 | 1.4.4.1 | Procure 2 Test Stands and MAPS Evaluation Modules |  | 180d | 2016-12-12 A | 2017-08-24 |  | 16% | 151d | 2016-12-12 | 2017-08-24 | 180d | 864d | 0d |  | Elec tech [5%]; Physicist [5%] | 100h | 40h | 58,148 | 58,148 | 10,328 |  | LDRD |
| 35 | 1.4.4.2 | Setup Test Stands |  | 20d | 2017-08-25 | 2017-09-22 | 34 |  |  | 2017-08-25 | 2017-09-22 | 20d | 864d | 95d |  | Physicist [20%]; LDRD PostDoc; LDRD Electronics Tech [50%] | 272h |  | 36,400 | 36,400 |  |  | LDRD |
| 36 | 1.4.5 | **Procure R&D ALICE Staves** |  | 176d | 2016-12-12 | 2017-08-18 |  |  |  | 2016-12-12 | 2017-08-18 | 176d |  |  |  |  | 4264h |  | 572,200 | 553,720 |  |  | LDRD |
| 37 | 1.4.5.1 | Procure 1 R&D Stave |  | 60d | 2017-03-01 | 2017-05-23 |  |  |  |  |  |  | -229d | 0d | start no earlier than 2017-03-01 |  |  |  | 12,000 |  |  |  |  |
| 38 | 1.4.5.2 | Test 1 R&D Stave at LANL |  | 90d | 2017-05-24 | 2017-09-29 | 37 |  |  |  |  |  | -229d | 0d |  | LDRD PostDoc [10%] | 72h |  | 6,480 |  |  |  |  |
| 39 | 1.4.5.3 | Procure and Produce 5 Staves |  | 180d | 2017-10-02 | 2018-06-21 | 38 |  |  | 2017-09-12 | 2018-06-01 | 180d | -229d | 0d |  | Physicist [50%]; LDRD Electronics Tech; LDRD PostDoc; LDRD Physicist [30%] | 4032h |  | 504,960 | 504,960 |  |  | LDRD |
| 40 | 1.4.5.4 | Test Staves at LANL |  | 20d | 2018-06-22 | 2018-07-19 | 39 |  |  | 2018-06-04 | 2018-06-29 | 20d | -229d | 0d |  | LDRD Physicist [20%]; LDRD PostDoc [50%]; LDRD Electronics Tech [30%] | 160h |  | 21,760 | 21,760 |  |  | LDRD |
| 41 | 1.4.5.5 | Travel and Per Diem Support |  | 180d | 2017-10-02 | 2018-06-21 | 39SS |  |  | 2017-09-12 | 2018-06-01 | 180d | -209d | 0d |  |  |  |  | 27,000 | 27,000 |  |  | LDRD |
| 42 | 1.4.6 | **Procure ALICE Readout Units** |  | 227d | 2017-05-01 | 2018-03-29 |  |  |  |  |  |  | 799d |  |  |  | 264h |  | 88,120 |  |  |  |  |
| 43 | 1.4.6.1 | Procure KC705/RU Mockup |  | 60d | 2017-05-01 | 2017-07-25 |  |  |  |  |  |  | 936d | 0d | start no earlier than 2017-05-01 |  |  |  | 5,000 |  |  |  |  |
| 44 | 1.4.6.2 | Test KC705/RU Mockup |  | 30d | 2017-07-26 | 2017-09-06 | 43 |  |  |  |  |  | 936d |  |  | LDRD Electronics Engineer [50%]; LDRD PostDoc [50%] | 240h |  | 38,400 |  |  |  |  |
| 45 | 1.4.6.3 | Procure RUv1.0 |  | 100d | 2017-06-01 | 2017-10-23 |  |  |  |  |  |  | 899d | 0d | start no earlier than 2017-06-01 |  |  |  | 7,000 |  |  |  |  |
| 46 | 1.4.6.4 | Test RUv1.0 |  | 5d | 2017-10-24 | 2017-10-30 | 45 |  |  |  |  |  | 899d |  |  | LDRD Electronics Engineer [50%]; LDRD PostDoc [50%] | 24h |  | 2,720 |  |  |  |  |
| 47 | 1.4.6.5 | Procure 5 RUs |  | 120d | 2017-10-02 | 2018-03-29 |  |  |  |  |  |  | 799d |  | start no earlier than 2017-10-02 |  |  |  | 35,000 |  |  |  |  |
| 48 | 1.4.7 | **Procure Backend Readout Units (FELIX)** |  | 180d | 2017-06-07 | 2018-02-28 |  |  |  | 2017-07-07 | 2018-02-01 | 140d | 645d |  |  |  | 283.2h |  | 71,580 | 34,640 |  |  |  |
| 49 | 1.4.7.1 | Procure FELIX v1.5 |  | 60d | 2017-06-07 | 2017-08-30 | 27FS+1d |  |  | 2017-07-07 | 2018-01-04 | 120d | 645d | 0d | start no earlier than 2017-06-07 | Physicist [2%]; LDRD Electronics Tech [2%] | 19.2h |  | 13,940 | 12,880 |  |  | LDRD |
| 50 | 1.4.7.2 | Test FELIX v1.5 at LANL |  | 30d | 2017-08-31 | 2017-10-13 | 49 |  |  | 2018-01-05 | 2018-02-01 | 20d | 820d | 0d |  | Physicist [10%]; LDRD Electronics Tech [30%]; LDRD PostDoc [50%]; LDRD Physicist [20%] | 264h |  | 32,640 | 21,760 |  |  | LDRD |
| 51 | 1.4.7.3 | Procure FELIX v2.0 |  | 90d | 2017-10-16 | 2018-02-28 | 50 |  |  |  |  |  | 820d |  | start no earlier than 2016-11-21 |  |  |  | 25,000 |  |  |  |  |

Notes:
- 26: LANL LDRD activities
- 27: Use ITS production line to train local people and produce staves for sPHENIX; / provide 1 FTE from 1/2017 - 6/2018+ for LDRD and later for sPHENIX
- 30: The readout test stand design has already been completed by ALICE.
- 32: Walt already obtained CAD model
- 34: Cost from Leo. Only a few custom boards, standard items standard: power supplies, etc. One stand would be procured early, one late, both under LDRD. / CERN-LANL MOU comes later in 2016, ~Dec. 2016? / Time needed to setup an CERN accout etc. may delay the actual procument date. MXL / Evaluation modules are 4-single chip modules
- 35: LDRD PD + Tech, working with external collaorators/physicists
- 39: work on MOU to get 4 staves as early as possible; within 60 from the production ; / train LANL staff for MAPS assembly and test. M&S $20K for 6 months
- 40: assume testing 1 stave every two days;
- 41: $4.5K/month including lodging(100) and per diem (50) 1 FTE (combination of PD and staff) / for 6 months;

| ID | WBS | Task | Duration | Start | Finish | Predecessors | Baseline start | Baseline finish | Baseline duration | Total slack | Free slack | Constraint | Resources | Work | Cost | Baseline cost | Institution |
| --- | --- | --- | --- | --- | --- | --- | --- | --- | --- | --- | --- | --- | --- | --- | --- | --- | --- |
| 52 | 1.4.8 | **SamTec Cables** | 32d | 2016-12-12 | 2017-01-25 |  | 2016-12-12 | 2017-01-25 | 32d | 1092d |  |  |  | 20h | 5,000 | 5,000 |  |
| 53 | 1.4.8.1 | Procure 7 SamTec Cables | 30d | 2016-12-12 | 2017-01-23 |  | 2016-12-12 | 2017-01-23 | 30d | 1092d | 0d | start no earlier than 2016-12-12 | LDRD Electronics Tech [5%] | 12h | 3,800 | 3,800 | LDRD |
| 54 | 1.4.8.2 | Test Cables | 2d | 2017-01-24 | 2017-01-25 | 53 | 2017-01-24 | 2017-01-25 | 2d | 1092d |  |  | LDRD Electronics Tech [50%] | 8h | 1,200 | 1,200 | LDRD |
| 55 | 1.4.9 | **Optical Cables** | 22d | 2016-12-13 | 2017-01-12 |  | 2016-12-13 | 2017-01-12 | 22d | 1101d |  |  |  | 16h | 2,900 | 2,900 |  |
| 56 | 1.4.9.1 | Procure 5 Optical Cables | 20d | 2016-12-13 | 2017-01-10 | 53SS+1d | 2016-12-13 | 2017-01-10 | 20d | 1101d | 0d |  | LDRD Electronics Tech [5%] | 8h | 1,700 | 1,700 | LDRD |
| 57 | 1.4.9.2 | Test Optical Cables | 2d | 2017-01-11 | 2017-01-12 | 56 | 2017-01-11 | 2017-01-12 | 2d | 1101d |  |  | LDRD Electronics Tech [50%] | 8h | 1,200 | 1,200 | LDRD |
| 58 | 1.4.10 | **Procure Ancillaries** | 344d | 2016-12-13 | 2018-04-26 |  | 2016-12-13 | 2017-04-25 | 94d | 93d |  |  |  | 180h | 125,292 | 64,292 | LDRD |
| 59 | 1.4.10.1 | Procure LV,HV,etc | 90d | 2016-12-13 | 2017-04-19 | 33SS+1d | 2016-12-13 | 2017-04-19 | 90d | 93d | 0d | start no earlier than 2016-10-03 | Physicist [5%]; LDRD Electronics Tech [5%] | 72h | 55,400 | 35,400 | LDRD |
| 60 | 1.4.10.2 | Procure Racks | 90d | 2016-12-15 | 2017-04-21 | 59SS+2d | 2016-12-15 | 2017-04-21 | 90d | 93d |  | start no earlier than 2016-10-03 | LDRD Electronics Tech [5%] | 36h | 15,400 | 15,400 | LDRD |
| 61 | 1.4.10.3 | Procure CAEN PS | 100d | 2017-12-01 | 2018-04-26 |  |  |  |  | 779d |  | start no earlier than 2017-12-01 |  |  | 20,000 |  |  |
| 62 | 1.4.10.4 | Procure PU | 30d | 2017-09-01 | 2017-10-16 |  |  |  |  | 849d | 59d | start no earlier than 2017-09-01 |  |  | 6,000 |  |  |
| 63 | 1.4.10.5 | Procure Chiller | 90d | 2017-05-01 | 2017-09-06 | 60SS+2d | 2016-12-19 | 2017-04-25 | 90d | 0d |  | start no earlier than 2017-05-01 | Physicist [5%]; Elec tech [5%] | 72h | 13,492 | 13,492 | LDRD |
| 64 | 1.4.10.6 | Procure Laser System | 90d | 2017-10-02 | 2018-02-15 |  |  |  |  | 769d | 0d | start no earlier than 2017-10-02 |  |  | 15,000 |  |  |
| 65 | 1.4.11 | **Readout R&D** | 281d | 2017-06-06 | 2018-07-18 |  | 2017-06-06 | 2018-06-19 | 260d | 463d |  |  |  | 5401.33h | 1,159,800 | 774,640 |  |
| 66 | 1.4.11.1 | **ALPIDE Evaluation and Optimization** | 60d | 2018-02-16 | 2018-05-10 | 35 |  |  |  | 769d |  |  | LDRD Physicist [5%]; LDRD PostDoc [10%] | 192h | 24,000 |  |  |
| 67 | 1.4.11.1.1 | Setup Laser System & ALPIDE evaluation | 60d | 2018-02-16 | 2018-05-10 | 64 |  |  |  | 769d |  |  | LDRD PostDoc [20%]; LDRD Physicist [5%] | 120h | 14,160 |  |  |
| 68 | 1.4.11.2 | **Firmware Development** | 201d | 2017-06-06 | 2018-03-28 |  | 2017-06-06 | 2018-04-16 | 214d | 463d |  |  | LDRD Electronics Engineer [50%] | 2729.33h | 565,400 | 322,000 |  |
| 69 | 1.4.11.2.1 | ROU Trigger/Control Modifications | 20d | 2017-06-06 | 2017-07-03 | 28 | 2017-06-06 | 2017-07-03 | 20d | 463d | 0d |  | LDRD Electronics Engineer | 160h | 36,800 | 36,800 |  |
| 70 | 1.4.11.2.2 | KC705 + FELIXv1.5 integration | 30d | 2017-08-31 | 2017-10-13 | 49, 69 |  |  |  | 645d | 0d |  | LDRD Electronics Engineer [50%]; LDRD PostDoc [50%] | 240h | 38,400 |  |  |
| 71 | 1.4.11.2.3 | ALPIDE+RU and FELIXv1.5 integration | 60d | 2017-10-16 | 2018-01-17 | 70 |  |  |  | 645d | 0d |  | LDRD Electronics Engineer [50%]; LDRD PostDoc [50%] | 480h | 76,800 |  |  |
| 72 | 1.4.11.2.4 | FELIX Data Aggregation | 40d | 2017-11-30 | 2018-01-31 | 71FS-30d | 2017-07-05 | 2017-08-29 | 40d | 720d | 0d |  | LDRD Electronics Engineer; LDRD PostDoc [10%] | 352h | 76,480 | 73,600 |  |
| 73 | 1.4.11.2.5 | RCDAQ Data Formatting | 40d | 2018-02-01 | 2018-03-28 | 72 | 2017-08-30 | 2017-10-26 | 40d | 720d | 0d |  | LDRD Electronics Engineer [50%]; LDRD PostDoc [20%] | 213.33h | 41,600 | 73,600 |  |
| 74 | 1.4.11.2.6 | ALPIDE+RU+FELIXv2.0 Integration | 60d | 2017-07-05 | 2017-09-27 | 69 | 2018-01-02 | 2018-02-19 | 35d | 463d | 0d |  | LDRD Electronics Engineer | 480h | 110,400 | 64,400 |  |
| 75 | 1.4.11.2.7 | FELIXv2.0+RCDAQ+GTM Integration | 40d | 2017-09-28 | 2017-11-28 | 74 |  |  |  | 881d |  |  |  |  |  |  |  |

Notes:
- 53: from DigiKey?
- 65: critical tasks

| ID | WBS | Task | Duration | Start | Finish | Predecessors | Baseline start | Baseline finish | Baseline duration | Total slack | Free slack | Constraint | Resources | Work | Cost | Baseline cost | Institution |
| --- | --- | --- | --- | --- | --- | --- | --- | --- | --- | --- | --- | --- | --- | --- | --- | --- | --- |
| 76 | 1.4.11.3 | **Validation Firmware Development** | 100d | 2018-03-01 | 2018-07-18 |  | 2017-06-06 | 2017-10-05 | 86d | 720d |  |  |  | 800h | 184,000 | 158,240 |  |
| 77 | 1.4.11.3.1 | Stave, RU & FELIX Simulation | 60d | 2018-03-01 | 2018-05-23 | 71 | 2017-06-06 | 2017-07-26 | 36d | 720d | 0d | start no earlier than 2018-03-01 | LDRD Electronics Engineer | 480h | 110,400 | 66,240 |  |
| 78 | 1.4.11.3.2 | State of Health of Full Readout Chain | 40d | 2018-05-24 | 2018-07-18 | 74, 77 | 2017-07-27 | 2017-10-05 | 50d | 720d |  |  | LDRD Electronics Engineer | 320h | 73,600 | 92,000 |  |
| 79 | 1.4.11.4 | **Software Development** | 130d | 2018-01-18 | 2018-07-18 | 28 | 2017-10-27 | 2018-06-19 | 160d | 645d |  |  |  | 1680h | 386,400 | 294,400 |  |
| 80 | 1.4.11.4.1 | RU/PU Controls | 60d | 2018-01-18 | 2018-04-11 | 62, 71 | 2018-01-31 | 2018-03-27 | 40d | 790d |  |  | LDRD Electronics Engineer | 480h | 110,400 | 73,600 |  |
| 81 | 1.4.11.4.2 | RU/FELIX Contorls | 40d | 2018-03-29 | 2018-05-23 | 73 | 2017-10-27 | 2018-01-02 | 40d | 720d | 0d |  | LDRD Electronics Engineer | 320h | 73,600 | 73,600 |  |
| 82 | 1.4.11.4.3 | RCDAQ and FELIX Readout/Aggregation and Formatting | 50d | 2018-05-10 | 2018-07-18 | 81FS-10d | 2018-01-03 | 2018-01-30 | 20d | 720d |  |  | LDRD Electronics Engineer | 400h | 92,000 | 36,800 |  |
| 83 | 1.4.11.4.4 | Hardware(PS,Slow Controls & Monitoring,etc) | 60d | 2018-01-18 | 2018-04-11 | 71 | 2018-05-23 | 2018-06-19 | 20d | 645d | 51d |  | LDRD Electronics Engineer | 480h | 110,400 | 36,800 |  |
| 84 | 1.4.12 | **Mechanical Support and Cooling** | 289d | 2017-01-23 | 2018-03-20 |  | 2017-01-23 | 2018-01-11 | 241d | -191d | 0d |  |  | 1152h | 259,040 | 257,240 |  |
| 85 | 1.4.12.1 | **Specifications & Design** | 49d | 2017-01-23 | 2017-03-31 |  | 2017-01-23 | 2017-03-31 | 49d |  |  |  |  | 552h | 109,040 | 65,120 |  |
| 86 | 1.4.12.1.1 | Review & Simulate Heat Load | 40d | 2017-04-03 | 2017-05-26 | 32 | 2017-01-24 | 2017-03-21 | 40d | -240d | 0d | start no earlier than 2017-04-03 | LDRD Mechnical Engineer [30%]; LDRD Physicist [20%]; LDRD PostDoc [20%] | 224h | 42,560 | 42,560 | LDRD |
| 87 | 1.4.12.1.2 | review mechanical tolerances/distortions | 10d | 2017-05-30 | 2017-06-12 | 86 | 2017-03-22 | 2017-04-04 | 10d | -240d | 0d | start no earlier than 2004-10-01 | LDRD Mechnical Engineer [30%]; LDRD Physicist [30%] | 48h | 11,040 | 11,040 | LDRD |
| 88 | 1.4.12.1.3 | review disassembly/repair options | 10d | 2017-06-13 | 2017-06-26 | 87 | 2017-04-05 | 2017-04-18 | 10d | -240d | 0d | start no earlier than 2004-10-01 | LDRD Mechnical Tech [50%]; LDRD Physicist [30%] | 64h | 11,520 | 11,520 | LDRD |
| 89 | 1.4.12.1.4 | MVTX Mechanical Frame Conceptual Design | 180d | 2017-06-27 | 2018-03-20 | 88 | 2017-04-19 | 2017-05-16 | 20d | -240d | 0d |  | LDRD Mechnical Engineer [5%]; LDRD Physicist [5%]; LDRD Mechnical Tech [5%] | 216h | 43,920 | 32,960 | LDRD |
| 90 | 1.4.12.2 | **Safety Systems** | 60d | 2017-12-01 | 2018-03-01 |  | 2017-08-17 | 2017-11-13 | 60d |  |  |  |  | 144h | 35,440 | 35,440 |  |
| 91 | 1.4.12.2.1 | review sensors & interlocks | 20d | 2017-12-01 | 2018-01-04 |  | 2017-08-17 | 2017-09-14 | 20d | 0d |  | start no earlier than 2017-12-01 | LDRD Electronics Tech [30%] | 48h | 7,200 | 7,200 | LDRD |
| 92 | 1.4.12.2.2 | electrical interlock design | 20d | 2018-01-05 | 2018-02-01 | 91 | 2017-09-15 | 2017-10-13 | 20d | 0d |  |  | LDRD Electronics Tech [30%] | 48h | 12,200 | 12,200 | LDRD |
| 93 | 1.4.12.2.3 | cooling interlocks design | 20d | 2018-02-02 | 2018-03-01 | 92 | 2017-10-16 | 2017-11-13 | 20d | 0d |  |  | LDRD Mechnical Engineer [30%] | 48h | 16,040 | 16,040 | LDRD |
| 94 | 1.4.12.3 | **Cooling System** | 100d | 2017-09-07 | 2018-02-06 | 63, 88 | 2017-05-17 | 2017-07-27 | 50d | 0d |  |  |  | 216h | 60,880 | 42,480 |  |
| 95 | 1.4.12.3.1 | Prototype Design (modify ALICE) | 30d | 2017-09-07 | 2017-10-19 | 86 | 2017-05-17 | 2017-05-31 | 10d | 0d |  |  | LDRD Mechnical Engineer [30%]; LDRD Physicist [20%] | 120h | 27,600 | 9,200 | LDRD |
| 96 | 1.4.12.3.2 | Chiller Fabrication | 60d | 2017-10-20 | 2018-01-23 | 95 | 2017-06-01 | 2017-07-13 | 30d | 0d |  |  |  |  | 10,000 | 10,000 |  |
| 97 | 1.4.12.3.3 | Cooling Mockup Test | 10d | 2018-01-24 | 2018-02-06 | 96 | 2017-07-14 | 2017-07-27 | 10d | 0d |  |  | LDRD Mechnical Tech [50%]; LDRD Physicist [20%]; LDRD PostDoc [50%] | 96h | 23,280 | 23,280 | LDRD |
| 98 | 1.4.12.4 | **Telescope frame** | 100d | 2017-09-01 | 2018-02-01 |  | 2017-06-01 | 2017-08-24 | 60d | 3d |  |  |  | 240h | 53,680 | 48,360 |  |
| 99 | 1.4.12.4.1 | Telescope Mechanical Frame Design | 40d | 2017-09-01 | 2017-10-30 | 87 | 2017-06-01 | 2017-06-14 | 10d | 3d | 0d | start no earlier than 2017-09-01 | LDRD Mechnical Engineer [5%]; LDRD Physicist [10%] | 48h | 11,040 | 7,360 | LDRD |
| 100 | 1.4.12.4.2 | Telescope frame production | 60d | 2017-10-31 | 2018-02-01 | 99 | 2017-07-28 | 2017-08-24 | 20d | 3d |  |  | LDRD Mechnical Engineer [10%]; LDRD Mechnical Tech [30%] | 192h | 42,640 | 20,880 | LDRD |

Notes:
- 90: monitoring temp, flow rates, I, V etc.

| ID | WBS | Task | Type | Duration | Start | Finish | Predecessors | Baseline start | Baseline finish | Baseline duration | Total slack | Free slack | Constraint | Resources | Work | Cost | Baseline cost | Institution | Text1 |
| --- | --- | --- | --- | --- | --- | --- | --- | --- | --- | --- | --- | --- | --- | --- | --- | --- | --- | --- | --- |
| 101 | 1.4.13 | **Telescope System Test** |  | 90d | 2018-02-07 | 2018-06-12 |  | 2017-08-25 | 2018-01-11 | 90d |  |  |  |  | 216h | 32,880 | 32,880 |  |  |
| 102 | 1.4.13.1 | Assemble Prototype |  | 30d | 2018-02-07 | 2018-03-20 | 97, 100 | 2017-08-25 | 2017-10-06 | 30d | 0d |  |  | LDRD Electronics Tech [20%]; LDRD Mechnical Tech [50%]; LDRD Physicist [10%]; LDRD PostDoc [30%] | 216h | 32,880 | 32,880 |  |  |
| 103 | 1.4.13.2 | Full Prototype System Test with Cosmics (4-stave+4RUs+1FELIX) |  | 60d | 2018-03-21 | 2018-06-12 | 102 | 2017-10-10 | 2018-01-11 | 60d | 0d |  |  |  |  |  |  |  |  |
| 104 | 1.4.14 | **Electronics and Mechanical Final Design Review (sPHENIX, TBD)** |  | 12d | 2018-07-25 | 2018-08-09 |  | 2018-06-20 | 2018-07-05 | 12d | 258d |  |  |  | 65.6h | 25,088 | 25,088 |  |  |
| 105 | 1.4.14.1 | Electronics Design Review |  | 1d | 2018-07-25 | 2018-07-25 | 74 | 2018-06-20 | 2018-06-20 | 1d | 258d | 0d | start no earlier than 2018-07-25 | LDRD Electronics Engineer; LDRD Physicist | 16h | 13,680 | 13,680 | LDRD |  |
| 106 | 1.4.14.2 | Incorporate Review Comments |  | 10d | 2018-07-26 | 2018-08-08 | 105 | 2018-06-21 | 2018-07-04 | 10d | 258d | 0d |  | LDRD Physicist [20%]; LDRD Electronics Engineer [30%] | 40h | 9,200 | 9,200 | LDRD |  |
| 107 | 1.4.14.3 | Complete Final Electronics Design | milestone | 1d | 2018-08-09 | 2018-08-09 | 106 | 2018-07-05 | 2018-07-05 | 1d | 258d | 0d |  | LDRD Physicist [20%]; LDRD Electronics Engineer | 9.6h | 2,208 | 2,208 | LDRD |  |
| 108 | 1.4.15 | **MVTX DOE Review (TBD)** |  | 12d | 2018-08-24 | 2018-09-10 |  | 2018-07-06 | 2018-07-23 | 12d | 682d |  |  |  | 156h | 35,880 | 35,880 |  |  |
| 109 | 1.4.15.1 | Final Design Review |  | 1d | 2018-08-24 | 2018-08-24 | 107FS+10d | 2018-07-06 | 2018-07-06 | 1d | 682d | 0d | start no earlier than 2017-11-01 | LDRD Electronics Engineer; LDRD Mechnical Engineer; LDRD Physicist | 24h | 5,520 | 5,520 | LDRD | DOE |
| 110 | 1.4.15.2 | Incorporate Review Comments |  | 10d | 2018-08-27 | 2018-09-07 | 109 | 2018-07-09 | 2018-07-20 | 10d | 682d | 0d |  | LDRD Electronics Engineer [50%]; LDRD Mechnical Engineer [50%]; LDRD Physicist [50%] | 120h | 27,600 | 27,600 | LDRD | DOE |
| 111 | 1.4.15.3 | Complete Final MAPS Design | milestone | 1d | 2018-09-10 | 2018-09-10 | 110 | 2018-07-23 | 2018-07-23 | 1d | 682d |  |  | LDRD Electronics Engineer [50%]; LDRD Mechnical Engineer [50%]; LDRD Physicist [50%] | 12h | 2,760 | 2,760 | LDRD | DOE |
| 112 | 1.4.16 | **Detector Optimization and Physics Simulations** |  | 200d | 2017-05-01 | 2018-02-20 |  | 2017-05-01 | 2018-02-20 | 200d | 826d |  |  |  | 1600h | 306,000 | 306,000 |  |  |
| 113 | 1.4.16.1 | MIE preproposal Development |  | 5mo | 2017-05-01 | 2017-09-20 |  | 2017-05-01 | 2017-09-20 | 5mo | 826d | 0d | start no earlier than 2017-05-01 | LDRD Physicist [50%]; LDRD PostDoc [50%] | 800h | 148,000 | 148,000 |  |  |
| 114 | 1.4.16.2 | MIE Full Development and Reviews |  | 100d | 2017-09-21 | 2018-02-20 | 113 | 2017-09-21 | 2018-02-20 | 100d | 826d |  |  | LDRD Physicist [50%]; LDRD PostDoc [50%] | 800h | 158,000 | 158,000 |  |  |
| 115 | 1.4.17 | **Test Beam Operation** |  | 332d | 2018-06-22 | 2019-09-30 |  | 2018-06-20 | 2021-04-21 | 741d | 135d |  |  |  | 2056h | 401,620 | 399,220 | LDRD |  |
| 116 | 1.4.17.1 | Cosmic Ray Run |  | 145d | 2018-06-22 | 2019-01-10 | 39, 83, 103 | 2018-06-20 | 2019-01-08 | 145d | 594d |  |  | LDRD Physicist | 1160h | 266,800 | 266,800 |  |  |
| 117 | 1.4.17.2 | Shipping/Transport to FNAL |  | 20d | 2018-12-28 | 2019-01-24 |  | 2019-01-11 | 2019-01-24 | 10d | 0d |  | as late as possible | LDRD Mechnical Tech [20%] | 32h | 14,800 | 12,400 | LDRD |  |
| 118 | 1.4.17.3 | Setup |  | 5d | 2019-01-25 | 2019-01-31 | 117 | 2019-01-25 | 2019-01-31 | 5d | 0d |  | as late as possible | Physicist [50%]; LDRD Electronics Tech [50%]; LDRD Mechnical Tech [50%]; LDRD PostDoc [50%]; LDRD Physicist [10%] | 84h | 8,720 | 8,720 | LDRD |  |
| 119 | 1.4.17.4 | Operations |  | 30d | 2019-02-01 | 2019-03-14 | 118 | 2019-02-01 | 2019-02-28 | 20d | 0d |  | must start on 2019-02-01 | Physicist; LDRD Physicist; LDRD PostDoc | 240h | 45,600 | 45,600 | LDRD |  |
| 120 | 1.4.17.5 | Test Beam Data Analysis & Publication |  | 67.5d | 2019-06-27 | 2019-09-30 | 119 | 2019-03-01 | 2021-04-21 | 219.5d | 407d |  | finish no earlier than 2019-09-30 | LDRD Physicist [50%]; LDRD PostDoc [50%]; Physicist [50%] | 540h | 65,700 | 65,700 |  |  |
| 121 | 1.4.18 | **Theoretical Efforts** |  | 767d | 2016-10-03 | 2019-09-30 |  |  |  |  | 407d |  |  |  | 5522.4h | 1,270,152 |  |  |  |
| 122 | 1.4.18.1 | pQCD |  | 767d | 2016-10-03 | 2019-09-30 |  |  |  |  | 407d |  | start no earlier than 2016-10-03 | LDRD Physicist [50%] | 3068h | 705,640 |  |  |  |
| 123 | 1.4.18.2 | LQCD |  | 767d | 2016-10-03 | 2019-09-30 |  |  |  |  | 407d |  |  | LDRD Physicist [20%] | 1227.2h | 282,256 |  |  |  |
| 124 | 1.4.18.3 | QMD |  | 767d | 2016-10-03 | 2019-09-30 |  |  |  |  | 407d |  |  | LDRD Physicist [20%] | 1227.2h | 282,256 |  |  |  |

Notes:
- 105: for CD-2

| ID | WBS | Task | Type | Duration | Start | Finish | Predecessors | Total slack | Free slack | Constraint | Resources | Work | Cost | Institution | Activity | Material contingency | Labor Contingency | Total Contingency | Text1 |
| --- | --- | --- | --- | --- | --- | --- | --- | --- | --- | --- | --- | --- | --- | --- | --- | --- | --- | --- | --- |
| 125 | 1.5 | **MVTX Project** |  | 1129d | 2018-09-03 | 2022-12-29 |  | -333d | 0d |  |  | 27397.9h | 4,737,660.19 |  |  |  |  |  |  |
| 126 | 1.5.1 | **MVTX Project Management** |  | 774d | 2018-10-01 | 2021-09-16 |  | 0d |  |  |  | 1857.6h | 721,999.84 | LANL | sPHENIX MAPS Project |  |  |  |  |
| 127 | 1.5.1.1 | Milestone Start MVTX | milestone | 0d | 2018-10-01 | 2018-10-01 |  | 2d | 0d | start no earlier than 2018-10-01 |  |  |  |  |  |  |  |  |  |
| 128 | 1.5.1.2 | lead Coordinator |  | 774d | 2018-10-01 | 2021-09-16 | 127 | 2d |  |  |  |  | 272,842 |  |  | .35 | .35 | .35 |  |
| 129 | 1.5.1.3 | Project Manager |  | 774d | 2018-10-01 | 2021-09-16 | 127 | 2d |  | finish no earlier than 2020-12-17 | MGR_Institution_LANL [20%] | 1238.4h | 311,213.6 |  |  | .35 | .35 | .35 |  |
| 130 | 1.5.1.4 | Mechanical Integration Engineer |  | 774d | 2018-10-01 | 2021-09-16 | 127 | 2d |  | finish no earlier than 2020-12-17 | PROF4_institution_LANL [5%] | 309.6h | 43,972.12 |  |  | .35 | .35 | .35 | DOE |
| 131 | 1.5.1.5 | Electronics Integration Engineer |  | 774d | 2018-10-01 | 2021-09-16 | 127 | 2d |  | finish no earlier than 2020-12-17 | PROF4_institution_LANL [5%] | 309.6h | 43,972.12 |  |  | .35 | .35 | .35 | DOE |
| 132 | 1.5.1.6 | Travel | manual | 342d | 2018-10-01 | 2020-01-21 | 127 |  |  | start no earlier than 2018-01-01 |  |  | 50,000 |  |  |  |  |  |  |
| 133 | 1.5.2 | **Electronics** |  | 492d | 2018-10-01 | 2020-08-18 |  | 107d |  |  |  | 4119.2h | 942,980.2 | LANL |  |  |  |  |  |
| 134 | 1.5.2.1 | **Stave Extension Cable** |  | 122d | 2019-09-04 | 2020-02-20 |  | 412d |  |  |  | 336h | 48,770 | LANL |  |  |  |  |  |
| 135 | 1.5.2.1.1 | design |  | 1mo | 2019-09-04 | 2019-10-01 | 223 | 412d | 0d |  | PROF4_institution_LANL | 160h | 22,097.2 |  |  | .35 | .35 | .35 |  |
| 136 | 1.5.2.1.2 | prototype |  | 2mo | 2019-10-02 | 2019-11-26 | 135 | 412d | 0d |  |  |  | 10,000 |  |  | .35 | .35 | .35 |  |
| 137 | 1.5.2.1.3 | review |  | 2d | 2019-11-27 | 2019-11-28 | 136 | 412d | 0d |  | PROF4_institution_LANL | 16h | 2,272.8 |  |  | .35 | .35 | .35 |  |
| 138 | 1.5.2.1.4 | procure |  | 2mo | 2019-11-29 | 2020-01-23 | 137 | 412d | 0d |  |  |  | 14,400 |  |  | .35 | .35 | .35 |  |
| 139 | 1.5.2.1.5 | test |  | 20d | 2020-01-24 | 2020-02-20 | 138 | 412d |  |  | SCI3_Institution_LANL | 160h |  |  |  | .35 | .35 | .35 |  |
| 140 | 1.5.2.2 | **RU** |  | 373d | 2019-03-15 | 2020-08-18 |  | 103d |  |  |  | 1088.8h | 479,682.78 |  |  |  |  |  |  |
| 141 | 1.5.2.2.1 | Produce RU first production unit |  | 4w | 2019-03-15 | 2019-04-11 | 107, 119 | 103d | 0d |  | TECH4_Institution_LANL [10%] | 16h | 12,545.6 |  |  | .35 | .35 | .35 |  |
| 142 | 1.5.2.2.2 | Procure SamTec Cable |  | 4w | 2019-03-15 | 2019-04-11 | 141SS | 377d | 0d |  | TECH4_Institution_LANL [5%] | 8h | 1,502.8 |  |  | .35 | .35 | .35 |  |
| 143 | 1.5.2.2.3 | Test/QA RU |  | 2w | 2019-04-12 | 2019-04-25 | 142 | 377d | 0d |  | SCI3_Institution_LANL [50%]; ElectTech_Institution_UTAustin [50%] | 80h | 3,600 |  |  | .35 | .35 | .35 |  |
| 144 | 1.5.2.2.4 | Procure 57Readout /RU Units |  | 250d | 2019-09-04 | 2020-08-18 | 143, 223 | 284d |  | start no earlier than 2016-10-03 | TECH4_Institution_LANL [1%] | 20h | 402,270.7 | LANL |  | .35 | .35 | .35 |  |
| 145 | 1.5.2.2.5 | Procure 60 SamTec Cables |  | 60d | 2019-04-26 | 2019-07-18 | 143 | 492d | 0d | finish no earlier than 2018-10-26 | TECH4_Institution_LANL [1%] | 4.8h | 14,563.68 | LANL |  | .35 | .35 | .35 |  |
| 146 | 1.5.2.2.6 | Test/QA |  | 60d | 2019-07-19 | 2019-10-10 | 145 | 492d | 0d |  | SCI3_Institution_LANL; ElectTech_Institution_UTAustin | 960h | 43,200 |  |  | .35 | .35 | .35 |  |
| 147 | 1.5.2.2.7 | Ship to BNL |  | 1w | 2019-10-11 | 2019-10-17 | 146 | 492d | 0d |  |  |  | 2,000 |  |  | .35 | .35 | .35 |  |
| 148 | 1.5.2.3 | **FELIX/CRU** |  | 176d | 2019-03-15 | 2019-11-15 |  | 103d |  |  |  | 193.6h | 114,978.69 |  |  |  |  |  |  |
| 149 | 1.5.2.3.1 | Produce first production unit |  | 4w | 2019-03-15 | 2019-04-11 | 107, 119 | 103d | 0d |  | TECH4_Institution_LANL [10%] | 16h | 17,545.6 |  |  | .35 | .35 | .35 |  |
| 150 | 1.5.2.3.2 | Procure Optical fiber |  | 2w | 2019-03-15 | 2019-03-28 | 149SS | 574d | 0d |  | TECH4_Institution_LANL [2%] | 1.6h | 304.56 |  |  | .35 | .35 | .35 |  |
| 151 | 1.5.2.3.3 | Test/QA |  | 2w | 2019-03-29 | 2019-04-11 | 150 | 574d | 0d |  | SCI3_Institution_LANL [50%] | 40h |  |  |  | .35 | .35 | .35 |  |
| 152 | 1.5.2.3.4 | Procure 7 Remaining Units |  | 8w | 2019-09-04 | 2019-10-29 | 143, 151, 223 | 471d | 0d | finish no earlier than 2018-12-20 | TECH4_Institution_LANL [2%] | 6.4h | 81,534.37 | LANL |  | .35 | .35 | .35 |  |
| 153 | 1.5.2.3.5 | Procure 57 optical fibers |  | 2w | 2019-04-12 | 2019-04-25 | 151 | 604d | 133d |  | TECH4_Institution_LANL [2%] | 1.6h | 3,104.56 |  |  | .35 | .35 | .35 |  |
| 154 | 1.5.2.3.6 | test/QA |  | 8d | 2019-10-30 | 2019-11-08 | 152, 153 | 471d | 0d |  | SCI3_Institution_LANL; TECH4_Institution_LANL | 128h | 10,489.6 |  |  | .35 | .35 | .35 |  |
| 155 | 1.5.2.3.7 | Ship to BNL |  | 1w | 2019-11-11 | 2019-11-15 | 154 | 471d | 0d |  |  |  | 2,000 |  |  | .35 | .35 | .35 |  |

Notes:
- 129: L3 project manager is on project
- 141: Use ALICE design files
- 149: Use ALICE design files

| ID | WBS | Task | Duration | Start | Finish | Predecessors | Total slack | Free slack | Constraint | Resources | Work | Cost | Institution | Material contingency | Labor Contingency | Total Contingency | Text1 |
| --- | --- | --- | --- | --- | --- | --- | --- | --- | --- | --- | --- | --- | --- | --- | --- | --- | --- |
| 156 | 1.5.2.4 | **MAPS Power System** | 225d | 2018-10-01 | 2019-08-09 |  | 107d |  |  |  | 2500.8h | 299,548.73 | LBNL |  |  |  |  |
| 157 | 1.5.2.4.1 | **Power Boards** | 175d | 2018-10-01 | 2019-05-31 |  | 107d |  |  |  | 2196h | 182,248.5 | LBNL |  |  |  |  |
| 158 | 1.5.2.4.1.1 | Review ALICE PB Design | 30d | 2018-10-01 | 2018-11-09 | 127 | 107d | 0d | start no earlier than 2017-11-01 | ELENG3_Institution_LBNL [35%]; MECHENG3_Institution_LBNL [10%]; POSTD_Institution_LBNL; STAFFPHYS_Institution_LBNL | 588h | 17,725.92 |  | .30 | .30 | .30 |  |
| 159 | 1.5.2.4.1.2 | Fabricate PB Prototype | 40d | 2018-11-12 | 2019-01-04 | 158 | 107d | 0d |  | ELENG3_Institution_LBNL [12.5%]; ELTECH4_Institution_LBNL [13%]; POSTD_Institution_LBNL [25%]; STAFFPHYS_Institution_LBNL [20%] | 225.6h | 16,861.46 |  | .35 | .35 | .35 |  |
| 160 | 1.5.2.4.1.3 | Procure Power Distribution | 20d | 2019-01-07 | 2019-02-01 | 159 | 107d | 0d |  | POSTD_Institution_LBNL; STAFFPHYS_Institution_LBNL | 320h | 1,000 |  | .35 | .35 | .35 |  |
| 161 | 1.5.2.4.1.4 | Test PB Prototype and Distribution | 20d | 2019-02-04 | 2019-03-01 | 160 | 107d | 0d |  | ELENG3_Institution_LBNL [25%]; ELTECH4_Institution_LBNL [25%]; POSTD_Institution_LBNL; STAFFPHYS_Institution_LBNL [50%]; GRSTUD_Institution_LBNL | 480h | 12,096.8 |  | .25 | .25 | .25 |  |
| 162 | 1.5.2.4.1.5 | Design Production PB | 20d | 2019-03-04 | 2019-03-29 | 159, 161 | 107d | 0d |  | ELENG3_Institution_LBNL [50%]; POSTD_Institution_LBNL; STAFFPHYS_Institution_LBNL [75%]; ELTECH4_Institution_LBNL [25%] | 400h | 19,777.2 |  | .35 | .35 | .35 |  |
| 163 | 1.5.2.4.1.6 | Hold Power system Review | 5d | 2019-04-01 | 2019-04-05 | 162 | 107d | 0d |  | ELENG3_Institution_LBNL [40%]; STAFFPHYS_Institution_LBNL; POSTD_Institution_LBNL | 96h | 2,732.16 |  |  |  |  |  |
| 164 | 1.5.2.4.1.7 | Fabricate Break Out Boards | 20d | 2019-04-08 | 2019-05-03 | 163 | 621d |  |  |  |  | 15,000 |  | .35 | .35 | .35 |  |
| 165 | 1.5.2.4.1.8 | Fabricate PB to Stave Cables | 20d | 2019-04-08 | 2019-05-03 | 163 | 621d |  |  |  |  | 5,000 |  | .35 | .35 | .35 |  |
| 166 | 1.5.2.4.1.9 | Fabricate Production PB | 40d | 2019-04-08 | 2019-05-31 | 163 | 601d |  | finish no earlier than 2018-06-01 | ELENG3_Institution_LBNL [13%]; POSTD_Institution_LBNL [25%]; STAFFPHYS_Institution_LBNL [25%]; ELTECH4_Institution_LBNL [13%] | 86.4h | 92,054.96 |  | .35 | .35 | .35 |  |
| 167 | 1.5.2.4.2 | **Power Supplies** | 90d | 2019-04-08 | 2019-08-09 |  | 551d |  |  |  | 304.8h | 117,300.23 |  |  |  |  |  |
| 168 | 1.5.2.4.2.1 | Procure and Integrate Power | 90d | 2019-04-08 | 2019-08-09 | 163 | 551d |  | finish no earlier than 2016-10-03 | ELENG3_Institution_LBNL [3%]; STAFFPHYS_Institution_LBNL [13%]; POSTD_Institution_LBNL [13%] | 208.8h | 98,488.42 |  | .35 | .35 | .35 |  |
| 169 | 1.5.2.4.2.2 | Procure and terminate PS-to-Pb | 30d | 2019-04-08 | 2019-05-17 | 163 | 594.67d | 0d |  | ELTECH4_Institution_LBNL [15%]; STAFFPHYS_Institution_LBNL [10%] | 40h | 12,146.56 |  | .35 | .35 | .35 |  |
| 170 | 1.5.2.4.2.3 | test PB with power supplies | 1w | 2019-05-20 | 2019-05-24 | 169 | 594.67d | 0d |  | ELTECH4_Institution_LBNL | 40h | 4,116.4 |  | .35 | .35 | .35 |  |
| 171 | 1.5.2.4.2.4 | Document | 1.33d | 2019-05-27 | 2019-05-28 | 170 | 594.67d | 0d |  | ELTECH4_Institution_LBNL [50%]; STAFFPHYS_Institution_LBNL; POSTD_Institution_LBNL | 16h | 548.85 |  | .35 | .35 | .35 |  |
| 172 | 1.5.2.4.2.5 | ship to BNL | 1w | 2019-05-28 | 2019-06-04 | 171 | 594.67d | 0d |  |  |  | 2,000 |  | .35 | .35 | .35 |  |
| 173 | 1.5.3 | **Mechanics and Detector Assembly** | 617d | 2018-09-03 | 2021-01-12 |  | 32d |  |  |  | 15611.9h | 2,365,728.55 | LBNL |  |  |  |  |
| 174 | 1.5.3.1 | **Staves** | 377d | 2018-09-03 | 2020-02-11 |  | 322d |  |  |  | 2709.53h | 1,234,144.66 |  |  |  |  |  |
| 175 | 1.5.3.1.1 | **Production** | 180d | 2018-09-03 | 2019-05-10 |  | 322d |  |  |  | 1455.76h | 1,033,425.99 |  |  |  |  |  |
| 176 | 1.5.3.1.1.1 | Produce 84 Inner Staves at CERN | 1d | 2018-09-03 | 2018-09-03 | 6 | 322d | 0d | start no earlier than 2018-09-03 | SCI3_Institution_LANL; STAFFPHYS_Institution_LBNL [12%] | 8.96h | 966,000 | LANL | .35 | .35 | .35 | DOE |
| 177 | 1.5.3.1.1.2 | Tests and QA at CERN | 180d | 2018-09-03 | 2019-05-10 | 176SS | 616d |  |  | SCI3_Institution_LANL | 1440h |  | LANL | .35 | .35 | .35 |  |
| 178 | 1.5.3.1.1.3 | CERN Test System | 1d | 2018-09-04 | 2018-09-04 | 176 | 322d | 223d | start no earlier than 2018-01-01 | ELENG3_Institution_LBNL [5%]; POSTD_Institution_LBNL [50%]; STAFFPHYS_Institution_LBNL [30%] | 6.8h | 7,425.99 | LANL | .35 | .35 | .35 |  |
| 179 | 1.5.3.1.1.4 | Travel and Per Diem at CERN | 1d | 2018-09-03 | 2018-09-03 | 176SS | 795d |  | start no earlier than 2016-10-03 |  |  | 50,000 | LANL | .35 | .35 | .35 |  |
| 180 | 1.5.3.1.1.5 | Ship to LBNL and customs | 1d | 2018-09-04 | 2018-09-04 | 176 | 322d | 223d |  |  |  | 10,000 | LANL | .25 | .25 | .25 |  |

Notes:
- 158: From ALICE PB prototype estimates, decreased MechEng effort, increased ElEng to adjust for group skills,
- 159: From ALICE PB prototype estimate
- 161: From ALICE PB prototype estimate
- 162: From ALICE PB estimates, decreased MechEng effort, increased ElEng to adjust for group skills,
- 163: From ALICE PB estimate
- 176: 48+20% = 58; consider to have 40% spare: 68 in total / could start early right after ITS production end, assuming sPHENIX can morgage with CERN to produce staves, can gain 6 months of advanced production; / production length ~ 6 months = 20x6days / fixed cost = 40 wafers(x2 needed) = $129470 / $558000 x68/120 = $316200 (scale from ALICE inner barrel cost for 120 good staves) / Total $445670
- 178: From ITS: possible small modification and setup
- 179: 1 FTE lodging(100) and per diem(50) for 6 months; / $4.5K/month x6 = 27,000

| ID | WBS | Task | Duration | Start | Finish | Predecessors | Total slack | Free slack | Constraint | Resources | Work | Cost | Institution | Material contingency | Labor Contingency | Total Contingency |
| --- | --- | --- | --- | --- | --- | --- | --- | --- | --- | --- | --- | --- | --- | --- | --- | --- |
| 181 | 1.5.3.1.2 | **Stave Assembly Tooling** | 115d | 2019-09-04 | 2020-02-11 |  | 419d |  |  |  | 344h | 106,328.72 |  |  |  |  |
| 182 | 1.5.3.1.2.1 | design | 1mo | 2019-09-04 | 2019-10-01 | 223 | 419d | 0d |  | MECHENG4_Institution_LBNL | 160h | 34,072 | LBNL | .35 | .35 | .35 |
| 183 | 1.5.3.1.2.2 | prototype | 30d | 2019-10-02 | 2019-11-12 | 182 | 419d | 0d |  | MECHTECH4_Institution_LBNL [50%] | 120h | 35,615.6 | LBNL | .35 | .35 | .35 |
| 184 | 1.5.3.1.2.3 | final jig design | 5d | 2019-11-13 | 2019-11-19 | 183 | 419d | 0d |  | MECHENG4_Institution_LBNL | 40h | 8,518 | LBNL | .35 | .35 | .35 |
| 185 | 1.5.3.1.2.4 | procure Assembly Fixtures and tooling | 60d | 2019-11-20 | 2020-02-11 | 184 | 419d |  |  | MECHTECH4_Institution_LBNL [5%] | 24h | 28,123.12 | LBNL | .35 | .35 | .35 |
| 186 | 1.5.3.1.3 | **Metrology** | 65d | 2019-09-04 | 2019-12-03 |  | 469d |  |  |  | 323.2h | 52,349.68 | LANL |  |  |  |
| 187 | 1.5.3.1.3.1 | Metrology design | 1mo | 2019-09-04 | 2019-10-01 | 223 | 469d | 0d |  | PROF4_institution_LANL | 160h | 22,097.2 |  | .35 | .35 | .35 |
| 188 | 1.5.3.1.3.2 | Design jigs | 20d | 2019-10-02 | 2019-10-29 | 187 | 469d | 0d |  | PROF4_institution_LANL | 160h | 22,728 |  | .35 | .35 | .35 |
| 189 | 1.5.3.1.3.3 | Procure jigs | 4w | 2019-10-30 | 2019-11-26 | 188 | 469d | 0d |  | TECH4_Institution_LANL [2%] | 3.2h | 5,524.48 |  | .35 | .35 | .35 |
| 190 | 1.5.3.1.3.4 | ship to LBNL | 1w | 2019-11-27 | 2019-12-03 | 189 | 469d |  |  |  |  | 2,000 |  | .35 | .35 | .35 |
| 191 | 1.5.3.1.4 | **Shipping and Storage Containers** | 312d | 2018-09-03 | 2019-11-12 |  | 349d |  |  |  | 586.57h | 42,040.27 | LBNL |  |  |  |
| 192 | 1.5.3.1.4.1 | Design&Fabricate Storage Cabinets for Staves | 39d | 2019-09-04 | 2019-10-28 | 127, 223 | 495d |  | start no earlier than 2017-11-01 | MECHTECH4_Institution_LBNL [13%]; STAFFPHYS_Institution_LBNL [25%]; POSTD_Institution_LBNL [50%] | 274.57h | 12,174.69 |  | .35 | .35 | .35 |
| 193 | 1.5.3.1.4.2 | Design&Fabricate Shipping and Storage Containers (Half-Barrels) | 50d | 2019-09-04 | 2019-11-12 | 127, 223 | 87d | 75d | start no earlier than 2017-11-01 | MECHTECH4_Institution_LBNL [10%]; STAFFPHYS_Institution_LBNL [25%]; POSTD_Institution_LBNL [33%] | 272h | 16,631.18 |  | .35 | .35 | .35 |
| 194 | 1.5.3.1.4.3 | Design shipping container for 84 staves | 1w | 2018-09-03 | 2018-09-07 | 176SS | 751d | 0d |  | MECHENG4_Institution_LBNL | 40h | 8,234.4 |  | .35 | .35 | .35 |
| 195 | 1.5.3.1.4.4 | ship to CERN | 2mo | 2018-09-10 | 2018-11-02 | 194 | 751d |  |  |  |  | 5,000 |  | .35 | .35 | .35 |
| 196 | 1.5.3.2 | **Carbon Structures** | 432d | 2018-10-01 | 2020-05-26 |  | 12d |  |  |  | 4772.4h | 915,831.07 | LBNL |  |  |  |
| 197 | 1.5.3.2.1 | **Mechanics Detector Design** | 80d | 2018-10-01 | 2019-01-18 |  | 12d |  |  |  | 640h | 88,256 | LANL |  |  |  |
| 198 | 1.5.3.2.1.1 | Develop MAPS inner tracker mechanical model | 4mo | 2018-10-01 | 2019-01-18 | 127 | 12d | 0d |  | PROF4_institution_LANL | 640h | 88,256 |  | .35 | .35 | .35 |
| 199 | 1.5.3.2.2 | **End Wheels** | 262d | 2019-01-21 | 2020-01-21 |  | 12d |  |  |  | 308h | 65,663.6 |  |  |  |  |
| 200 | 1.5.3.2.2.1 | Design | 15d | 2019-01-21 | 2019-02-08 | 198 | 127d | 0d |  | PROF4_institution_LANL | 120h | 16,548 |  | .30 | .30 | .30 |
| 201 | 1.5.3.2.2.2 | Prototype | 30d | 2019-02-11 | 2019-03-22 | 200 | 127d | 0d |  | TECH4_Institution_LANL [5%] | 12h | 11,909.2 |  | .30 | .30 | .30 |
| 202 | 1.5.3.2.2.3 | Review | 2d | 2019-03-25 | 2019-03-26 | 201 | 127d | 115d |  | PROF4_institution_LANL | 16h | 2,206.4 |  | .30 | .30 | .30 |
| 203 | 1.5.3.2.2.4 | Procure end-wheels | 100d | 2019-09-04 | 2020-01-21 | 202, 223 | 12d | 0d | start no earlier than 2018-08-08 | STAFFPHYS_Institution_LBNL [10%]; POSTD_Institution_LBNL [10%] | 160h | 35,000 | LBNL | .30 | .30 | .30 |
| 204 | 1.5.3.2.3 | **Mechanics Fabrication** | 432d | 2018-10-01 | 2020-05-26 |  | 92d |  |  |  | 3600.4h | 718,229.87 |  |  |  |  |
| 205 | 1.5.3.2.3.1 | Travel LBNL | 50d | 2018-10-01 | 2018-12-07 | 127 | 726d |  | start no earlier than 2017-11-01 |  |  | 70,000 |  | .35 | .35 | .35 |

Notes:
- 192: From ITS
- 193: From ITS
- 203: from Luciano/Dave estimates

| ID | WBS | Task | Type | Duration | Start | Finish | Predecessors | Total slack | Free slack | Constraint | Resources | Work | Cost | Institution | Material contingency | Labor Contingency | Total Contingency |
| --- | --- | --- | --- | --- | --- | --- | --- | --- | --- | --- | --- | --- | --- | --- | --- | --- | --- |
| 206 | 1.5.3.2.3.2 | **CYSS Cylindrical Structure** |  | 242d | 2019-01-21 | 2019-12-24 | 198 | 12d |  |  |  | 1848.8h | 319,187.2 | LBNL |  |  |  |
| 207 | 1.5.3.2.3.2.1 | Review CYSS Design-Fabrication Compatibility |  | 40d | 2019-01-21 | 2019-03-15 | 198, 127 | 12d | 0d |  | MECHENG4_Institution_LBNL [16%]; STAFFPHYS_Institution_LBNL [50%]; POSTD_Institution_LBNL [50%] | 91.2h | 10,567.26 |  | .30 | .30 | .30 |
| 208 | 1.5.3.2.3.2.2 | modify design |  | 1mo | 2019-03-18 | 2019-04-12 | 207 | 12d | 0d |  | PROF4_institution_LANL | 160h | 22,064 |  | .30 | .30 | .30 |
| 209 | 1.5.3.2.3.2.3 | Review CYSS Design-Fabrication |  | 15d | 2019-04-15 | 2019-05-03 | 208 | 12d | 0d |  | MECHENG4_Institution_LBNL [25%]; MECHENG3_Institution_LBNL [33%]; POSTD_Institution_LBNL [20%]; STAFFPHYS_Institution_LBNL [20%] | 117.6h | 11,968.93 |  | .20 | .20 | .20 |
| 210 | 1.5.3.2.3.2.4 | Procure CYSS Material |  | 5d | 2019-05-06 | 2019-05-10 | 209 | 244d | 82d |  | STAFFPHYS_Institution_LBNL [20%] | 8h | 15,640 | LBNL | .30 | .30 | .30 |
| 211 | 1.5.3.2.3.2.5 | Production & Test CYSS |  | 80d | 2019-09-04 | 2019-12-24 | 210, 223 | 162d | 0d |  | CMMTECH4_Institution_LBNL [20%]; MACH4_Institution_LBNL [40%]; MECHTECH4_Institution_LBNL [60%]; MECHENG3_Institution_LBNL [65%]; MECHENG4_Institution_LBNL [10%]; STAFFPHYS_Institution_LBNL [25%]; POSTD_Institution_LBNL [10%] | 1472h | 258,947.01 | LBNL | .30 | .30 | .30 |
| 212 | 1.5.3.2.3.2.6 | Milestone: Complete CYSS | milestone | 0d | 2019-12-24 | 2019-12-24 | 211 | 172d | 160d |  |  |  |  | LBNL |  |  |  |
| 213 | 1.5.3.2.3.3 | **COSS Conical Half Shells** |  | 277d | 2019-05-06 | 2020-05-26 |  | 12d |  |  |  | 1751.6h | 329,042.68 | LBNL |  |  |  |
| 214 | 1.5.3.2.3.3.1 | Review COSS Design-Fabrication Compatibility |  | 40d | 2019-05-06 | 2019-06-28 | 198, 127, 209 | 12d | 0d |  | MECHENG4_Institution_LBNL [16%]; STAFFPHYS_Institution_LBNL [50%]; POSTD_Institution_LBNL [50%] | 91.2h | 10,903.04 |  | .30 | .30 | .30 |
| 215 | 1.5.3.2.3.3.2 | modify design |  | 1mo | 2019-07-01 | 2019-07-26 | 214 | 12d | 0d |  | PROF4_institution_LANL | 160h | 22,064 |  | .30 | .30 | .30 |
| 216 | 1.5.3.2.3.3.3 | Hold COSS Review (PRR) |  | 15d | 2019-07-29 | 2019-08-16 | 209, 215 | 12d | 0d |  | MECHENG3_Institution_LBNL [33%]; MECHENG4_Institution_LBNL [20%]; STAFFPHYS_Institution_LBNL [20%]; POSTD_Institution_LBNL [20%] | 111.6h | 10,691.23 |  | .30 | .30 | .30 |
| 217 | 1.5.3.2.3.3.4 | Procure COSS Material |  | 5d | 2019-08-19 | 2019-08-23 | 216 | 249d | 87d | start no earlier than 2005-04-01 | STAFFPHYS_Institution_LBNL [20%] | 8h | 15,640 | LBNL | .30 | .30 | .30 |
| 218 | 1.5.3.2.3.3.5 | Production & Test COSS |  | 110d | 2019-12-25 | 2020-05-26 | 217, 211, 223 | 162d | 0d |  | MACH4_Institution_LBNL [30%]; MECHENG3_Institution_LBNL [50%]; MECHENG4_Institution_LBNL [6%]; MECHTECH4_Institution_LBNL [40%]; CMMTECH4_Institution_LBNL [15%]; STAFFPHYS_Institution_LBNL [25%]; POSTD_Institution_LBNL [10%] | 1380.8h | 269,744.41 | LBNL | .30 | .30 | .30 |
| 219 | 1.5.3.2.3.3.6 | Milestone: Complete COSS | milestone | 0d | 2020-05-26 | 2020-05-26 | 218 | 162d | 130d |  |  |  |  | LBNL |  |  |  |
| 220 | 1.5.3.2.4 | **MVTX Final Design Review** |  | 12d | 2019-08-19 | 2019-09-03 |  | 12d |  |  |  | 224h | 43,681.6 |  |  |  |  |
| 221 | 1.5.3.2.4.1 | MVTX Design Review |  | 2d | 2019-08-19 | 2019-08-20 | 216, 198, 163, 141, 149, 209 | 12d | 0d |  | MECHENG4_Institution_LBNL; STAFFPHYS_Institution_LBNL; PROF4_institution_LANL; SCI3_Institution_LANL | 64h | 15,613.6 | ALL | .1 | .1 | .1 |
| 222 | 1.5.3.2.4.2 | Incorporate review comments |  | 9d | 2019-08-21 | 2019-09-02 | 221 | 12d | 0d |  | MECHENG4_Institution_LBNL; PROF4_institution_LANL | 144h | 25,261.2 | ALL | .10 | .10 | .10 |
| 223 | 1.5.3.2.4.3 | Complete Final Design |  | 1d | 2019-09-03 | 2019-09-03 | 222 | 12d | 0d |  | MECHENG4_Institution_LBNL; PROF4_institution_LANL | 16h | 2,806.8 | ALL | .10 | .10 | .10 |
| 224 | 1.5.3.3 | **Barrel Assembly** |  | 392d | 2019-07-12 | 2021-01-12 |  | 99d |  |  |  | 8130h | 215,752.81 |  |  |  |  |
| 225 | 1.5.3.3.1 | **Assembly and Testing** |  | 392d | 2019-07-12 | 2021-01-12 |  | 99d |  |  |  | 8130h | 215,752.81 |  |  |  |  |
| 226 | 1.5.3.3.1.1 | Receive 84 Staves from CERN | milestone | 0d | 2019-07-12 | 2019-07-12 | 176, 180 | 99d | 0d | finish no earlier than 2019-07-12 |  |  |  | LBNL |  |  |  |
| 227 | 1.5.3.3.1.2 | Test and Rework Staves |  | 50d | 2019-07-15 | 2019-09-20 | 226, 161, 178 | 99d | 87d |  | ELENG3_Institution_LBNL [10%]; MECHENG3_Institution_LBNL [8%]; ELTECH4_Institution_LBNL [20%]; POSTD_Institution_LBNL; STAFFPHYS_Institution_LBNL [50%]; GRSTUD_Institution_LBNL | 1152h | 19,572.64 | LBNL | .30 | .30 | .30 |
| 228 | 1.5.3.3.1.3 | **Layer Assembly and Test** |  | 140d | 2020-01-22 | 2020-08-04 |  | 12d |  |  |  | 2885.2h | 66,543.3 | LBNL |  |  |  |
| 229 | 1.5.3.3.1.3.1 | Test Installation of Staves onto Layer End-Wheels |  | 20d | 2020-01-22 | 2020-02-18 | 227, 203 | 12d | 0d |  | MECHENG3_Institution_LBNL [10%]; MECHTECH4_Institution_LBNL [20%]; POSTD_Institution_LBNL; STAFFPHYS_Institution_LBNL | 368h | 6,496.48 | LBNL | .35 | .35 | .35 |
| 230 | 1.5.3.3.1.3.2 | Hold Half-Detector Assembly Review (PRR) |  | 5d | 2020-02-19 | 2020-02-25 | 229 | 12d | 0d |  | MECHENG3_Institution_LBNL [40%]; POSTD_Institution_LBNL; STAFFPHYS_Institution_LBNL | 96h | 2,332.32 | LBNL | .20 | .20 | .20 |
| 231 | 1.5.3.3.1.3.3 | Install Staves Onto Layer End-Wheels To Form Layers |  | 70d | 2020-02-26 | 2020-06-02 | 230, 193 | 12d | 0d |  | MECHENG3_Institution_LBNL [10%]; ELENG3_Institution_LBNL [10%]; POSTD_Institution_LBNL; STAFFPHYS_Institution_LBNL [25%]; ELTECH4_Institution_LBNL [20%]; GRSTUD_Institution_LBNL | 1484h | 32,791.12 | LBNL | .40 | .40 | .40 |
| 232 | 1.5.3.3.1.3.4 | Test and Rework Layers After Assembly |  | 30d | 2020-06-03 | 2020-07-14 | 231 | 12d | 0d |  | ELENG3_Institution_LBNL [10%]; MECHENG3_Institution_LBNL [17%]; ELTECH4_Institution_LBNL [10%]; POSTD_Institution_LBNL; STAFFPHYS_Institution_LBNL [33%]; GRSTUD_Institution_LBNL | 648h | 15,329.1 | LBNL | .35 | .35 | .35 |
| 233 | 1.5.3.3.1.3.5 | Perform Half-Detector Metrology On Layers |  | 15d | 2020-07-15 | 2020-08-04 | 232 | 12d | 0d |  | CMMTECH4_Institution_LBNL [66%]; STAFFPHYS_Institution_LBNL [25%]; POSTD_Institution_LBNL; GRSTUD_Institution_LBNL [50%] | 289.2h | 9,594.29 | LBNL | .35 | .35 | .35 |
| 234 | 1.5.3.3.1.3.6 | Milestone: Complete Layers | milestone | 0d | 2020-08-04 | 2020-08-04 | 233 | 12d | 0d |  |  |  |  | LBNL |  |  |  |

Notes:
- 207: assuming design is final and we are just reviewing compatibility
- 209: similar review for OB
- 210: 50% OB-CYSS material
- 211: ~66% OB-COSS
- 214: assuming design is final and we are just reviewing compatibility
- 216: similar review for OB
- 217: ~90% OB-COSS material
- 218: ~ OB-CYSS, from Luciano's estimates and CYSS dimensions
- 227: From ITS estimates, scaled to the number of staves
- 229: From previous projects and ITS OB model
- 231: From previous projects and ITS OB model
- 232: From ITS estimates, scaled to the number of staves
- 233: From previous estimates and ITS OB model

| ID | WBS | Task | Type | Duration | Start | Finish | Predecessors | Total slack | Free slack | Constraint | Resources | Work | Cost | Institution | Material contingency | Labor Contingency | Total Contingency | Text1 |
| --- | --- | --- | --- | --- | --- | --- | --- | --- | --- | --- | --- | --- | --- | --- | --- | --- | --- | --- |
| 235 | 1.5.3.3.1.4 | **Half Barrel #1 Assembly and Test** |  | 95d | 2020-08-05 | 2020-12-15 |  | 12d |  |  |  | 2046.4h | 64,605.64 | LBNL |  |  |  |  |
| 236 | 1.5.3.3.1.4.1 | Assemble Layers and CYSS Into Half-Detector |  | 20d | 2020-08-05 | 2020-09-01 | 234, 212 | 12d | 0d |  | ELENG3_Institution_LBNL [10%]; MECHENG3_Institution_LBNL [25%]; ELTECH4_Institution_LBNL [20%]; POSTD_Institution_LBNL; STAFFPHYS_Institution_LBNL [50%]; GRSTUD_Institution_LBNL [50%] | 408h | 14,838.8 | LBNL | .40 | .40 | .40 |  |
| 237 | 1.5.3.3.1.4.2 | Test and Rework Half-Detector |  | 30d | 2020-09-02 | 2020-10-13 | 236 | 184d | 0d |  | ELENG3_Institution_LBNL [10%]; MECHENG3_Institution_LBNL [20%]; ELTECH4_Institution_LBNL [20%]; POSTD_Institution_LBNL; STAFFPHYS_Institution_LBNL [33%]; GRSTUD_Institution_LBNL | 679.2h | 19,136.48 | LBNL | .35 | .35 | .35 |  |
| 238 | 1.5.3.3.1.4.3 | Perform Half-Detector Metrology On Final Assembly |  | 10d | 2020-10-14 | 2020-10-27 | 237 | 184d | 0d |  | CMMTECH4_Institution_LBNL [70%]; STAFFPHYS_Institution_LBNL [50%]; POSTD_Institution_LBNL; GRSTUD_Institution_LBNL [50%] | 216h | 7,048.41 | LBNL | .35 | .35 | .35 |  |
| 239 | 1.5.3.3.1.4.4 | Validation Of Final Assembly |  | 20d | 2020-10-28 | 2020-11-24 | 238 | 184d | 0d |  | ELENG3_Institution_LBNL [10%]; MECHENG3_Institution_LBNL [10%]; CMMTECH4_Institution_LBNL [15%]; POSTD_Institution_LBNL; STAFFPHYS_Institution_LBNL; MECHTECH4_Institution_LBNL [20%]; GRSTUD_Institution_LBNL | 568h | 15,283.05 | LBNL | .35 | .35 | .35 |  |
| 240 | 1.5.3.3.1.4.5 | Pack/Ship Final Assemblies To BNL |  | 15d | 2020-11-25 | 2020-12-15 | 239, 219 | 184d | 0d |  | MECHENG3_Institution_LBNL [13%]; MECHTECH4_Institution_LBNL [13%]; POSTD_Institution_LBNL; STAFFPHYS_Institution_LBNL [20%] | 175.2h | 8,298.9 | LBNL | .35 | .35 | .35 |  |
| 241 | 1.5.3.3.1.5 | **Half Barrel #2 Assembly and Test** |  | 95d | 2020-09-02 | 2021-01-12 |  | 12d |  |  |  | 2046.4h | 65,031.23 | LBNL |  |  |  |  |
| 242 | 1.5.3.3.1.5.1 | Assemble Layers and CYSS Into Half-Detector |  | 20d | 2020-09-02 | 2020-09-29 | 234, 236, 212 | 12d | 0d |  | ELENG3_Institution_LBNL [10%]; MECHENG3_Institution_LBNL [25%]; ELTECH4_Institution_LBNL [20%]; POSTD_Institution_LBNL; STAFFPHYS_Institution_LBNL [50%]; GRSTUD_Institution_LBNL [50%] | 408h | 14,838.8 | LBNL | .40 | .40 | .40 |  |
| 243 | 1.5.3.3.1.5.2 | Test and Rework Half-Detector |  | 30d | 2020-09-30 | 2020-11-10 | 242 | 12d | 0d |  | ELENG3_Institution_LBNL [10%]; MECHENG3_Institution_LBNL [20%]; ELTECH4_Institution_LBNL [20%]; POSTD_Institution_LBNL; STAFFPHYS_Institution_LBNL [33%]; GRSTUD_Institution_LBNL | 679.2h | 19,562.07 | LBNL | .35 | .35 | .35 |  |
| 244 | 1.5.3.3.1.5.3 | Perform Half-Detector Metrology On Final Assembly |  | 10d | 2020-11-11 | 2020-11-24 | 243 | 12d | 0d |  | CMMTECH4_Institution_LBNL [70%]; STAFFPHYS_Institution_LBNL [50%]; POSTD_Institution_LBNL; GRSTUD_Institution_LBNL [50%] | 216h | 7,048.41 | LBNL | .35 | .35 | .35 |  |
| 245 | 1.5.3.3.1.5.4 | Validation Of Final Assembly |  | 20d | 2020-11-25 | 2020-12-22 | 244 | 12d | 0d |  | ELENG3_Institution_LBNL [10%]; MECHENG3_Institution_LBNL [10%]; CMMTECH4_Institution_LBNL [15%]; POSTD_Institution_LBNL; STAFFPHYS_Institution_LBNL; MECHTECH4_Institution_LBNL [20%]; GRSTUD_Institution_LBNL | 568h | 15,283.05 | LBNL | .35 | .35 | .35 |  |
| 246 | 1.5.3.3.1.5.5 | Pack/Ship Final Assemblies To BNL |  | 15d | 2020-12-23 | 2021-01-12 | 245, 219 | 12d | 0d |  | MECHENG3_Institution_LBNL [13%]; MECHTECH4_Institution_LBNL [13%]; POSTD_Institution_LBNL; STAFFPHYS_Institution_LBNL [20%] | 175.2h | 8,298.9 | LBNL | .35 | .35 | .35 |  |
| 247 | 1.5.3.3.1.5.6 | Milestone: Complete Barrel (RR) | milestone | 0d | 2021-01-12 | 2021-01-12 | 246 | 179d |  | start no earlier than 2016-10-03 |  |  |  | LBNL |  |  |  |  |
| 248 | 1.5.4 | **Integration and Infrastructure** |  | 1109d | 2018-10-01 | 2022-12-29 |  | -333d | 0d |  |  | 5809.2h | 706,951.61 |  |  |  |  |  |
| 249 | 1.5.4.1 | Clean Tent/Room |  | 100d | 2018-10-01 | 2019-02-15 | 127 | 676d |  | start no earlier than 2016-10-03 |  |  | 50,000 |  | .35 | .35 | .35 |  |
| 250 | 1.5.4.2 | **Cooling System** |  | 700d | 2018-10-01 | 2021-06-04 |  | 76d |  |  |  | 152h | 105,431.01 | MIT |  |  |  |  |
| 251 | 1.5.4.2.1 | travel |  | 700d | 2018-10-01 | 2021-06-04 | 127 | 76d |  |  |  |  | 25,000 |  | .35 | .35 | .35 |  |
| 252 | 1.5.4.2.2 | Design (modify ALICE) |  | 1w | 2019-09-04 | 2019-09-10 | 223 | 379d | 0d |  | PROF4_Institution_MIT | 40h | 6,520 |  | .35 | .35 | .35 |  |
| 253 | 1.5.4.2.3 | Mock up Testing |  | 1w | 2019-09-11 | 2019-09-17 | 252 | 379d | 0d |  | TECH4_Institution_MIT | 40h | 23,820 |  | .35 | .35 | .35 |  |
| 254 | 1.5.4.2.4 | Final Design of Cooling System |  | 5d | 2019-09-18 | 2019-09-24 | 253 | 379d | 0d |  | PROF4_Institution_MIT | 40h | 6,520 |  | .35 | .35 | .35 |  |
| 255 | 1.5.4.2.5 | Procure Cooling Plant |  | 100d | 2019-09-25 | 2020-02-11 | 254 | 394d | 0d | start no earlier than 2018-08-06 | SCI3_Institution_MIT [2%]; TECH4_Institution_MIT [2%] | 32h | 41,571.01 | MIT | .35 | .35 | .35 | DOE |
| 256 | 1.5.4.2.6 | Ship to BNL |  | 1w | 2020-02-12 | 2020-02-18 | 255 | 394d | 0d |  |  |  | 2,000 |  | .35 | .35 | .35 |  |
| 257 | 1.5.4.3 | **Safety Systems** |  | 700d | 2018-10-01 | 2021-06-04 |  | 76d |  |  |  | 986.4h | 139,292.96 | MIT |  |  |  |  |
| 258 | 1.5.4.3.1 | travel |  | 700d | 2018-10-01 | 2021-06-04 | 127 | 76d |  |  |  |  | 25,000 |  | .35 | .35 | .35 |  |
| 259 | 1.5.4.3.2 | Define MVTX Safety and Interlock requirements |  | 2w | 2019-09-25 | 2019-10-08 | 254, 223 | 379d | 0d |  | STAFFPHYS_Institution_LBNL [50%]; POSTD_Institution_LBNL [50%]; PROF4_Institution_MIT [50%] | 120h | 6,640 | LBNL | .35 | .35 | .35 |  |
| 260 | 1.5.4.3.3 | review sensors & interlocks with BNL ES&H |  | 10d | 2019-10-09 | 2019-10-22 | 259 | 379d | 0d |  | PROF4_Institution_MIT [50%]; STAFFPHYS_Institution_LBNL [50%] | 80h | 6,720 | LBNL | .15 | .15 | .15 |  |
| 261 | 1.5.4.3.4 | Design electronics safety system |  | 4w | 2019-10-23 | 2019-11-19 | 260 | 379d | 0d |  | ELENG3_Institution_LBNL [40%]; STAFFPHYS_Institution_LBNL [50%]; POSTD_Institution_LBNL [50%]; PROF4_Institution_MIT [40%] | 288h | 22,056.96 | LBNL | .35 | .35 | .35 |  |
| 262 | 1.5.4.3.5 | cooling interlocks design |  | 30d | 2019-11-20 | 2019-12-31 | 261 | 379d | 0d |  | PROF4_Institution_MIT [50%] | 120h | 20,160 |  | .35 | .35 | .35 |  |
| 263 | 1.5.4.3.6 | Procure Safety Systems |  | 8w | 2020-01-01 | 2020-02-25 | 262 | 379d | 0d |  | TECH4_Institution_MIT [5%]; PROF4_Institution_MIT [13%] | 57.6h | 18,561.6 |  | .35 | .35 | .35 |  |
| 264 | 1.5.4.3.7 | Test |  | 3w | 2020-02-26 | 2020-03-17 | 263 | 379d | 0d |  | TECH4_Institution_MIT; PROF4_Institution_MIT [34%] | 160.8h | 18,650.4 |  | .35 | .35 | .35 |  |
| 265 | 1.5.4.3.8 | Ship to BNL |  | 1w | 2020-03-18 | 2020-03-24 | 264 | 379d | 0d |  |  |  | 200 |  | .35 | .35 | .35 |  |
| 266 | 1.5.4.3.9 | Test at BNL |  | 2w | 2020-03-25 | 2020-04-07 | 265 | 379d |  |  | TECH4_Institution_MIT; PROF4_Institution_MIT | 160h | 21,304 |  | .35 | .35 | .35 |  |

Notes:
- 236: Scaled from previous project
- 237: Scaled from previous project
- 238: Scaled from previous project
- 239: Scaled from previous project
- 240: Scaled from previous project
- 242: Scaled from previous project
- 243: Scaled from previous project
- 244: Scaled from previous project
- 245: Scaled from previous project
- 246: Scaled from previous project
- 248: critical to have early R&D fund to finish mechanics for CD-2/CD3
- 257: monitoring temp, flow rates, I, V etc.

| ID | WBS | Task | Type | Duration | Start | Finish | Predecessors | Total slack | Free slack | Constraint | Resources | Work | Cost | Institution | Material contingency | Labor Contingency | Total Contingency | Text1 |
| --- | --- | --- | --- | --- | --- | --- | --- | --- | --- | --- | --- | --- | --- | --- | --- | --- | --- | --- |
| 267 | 1.5.4.4 | **Stave Support Frame &Global Interface to sPHENIX** |  | 300d | 2019-09-04 | 2020-10-27 | 223 | 234d |  |  |  | 1454.8h | 308,279.38 | LANL |  |  |  |  |
| 268 | 1.5.4.4.1 | travel |  | 300d | 2019-09-04 | 2020-10-27 |  | 234d |  |  |  |  | 20,000 |  | .1 | .1 | .1 |  |
| 269 | 1.5.4.4.2 | Design Interface to sPHENIX |  | 100d | 2019-09-04 | 2020-01-21 | 198 | 343.5d | 0d |  | PROF4_institution_LANL | 800h | 113,009.2 |  | .50 | .50 | .50 |  |
| 270 | 1.5.4.4.3 | FEA,Thermal,stress analysis |  | 30d | 2020-04-01 | 2020-05-12 | 198, 271 | 354d |  |  | PROF4_institution_LANL | 240h | 34,092 |  | .50 | .50 | .50 |  |
| 271 | 1.5.4.4.4 | design interface to rail system |  | 10w | 2020-01-22 | 2020-03-31 | 223, 269 | 343.5d | 0d |  | PROF4_institution_LANL | 400h | 56,820 |  | .50 | .50 | .50 |  |
| 272 | 1.5.4.4.5 | procure support structure |  | 8w | 2020-01-22 | 2020-03-17 | 269 | 394d |  |  | TECH4_Institution_LANL [2%] | 6.4h | 41,048.96 |  | .50 | .50 | .50 |  |
| 273 | 1.5.4.4.6 | Procure rail interface |  | 8w | 2020-04-01 | 2020-05-26 | 271 | 343.5d | 0d |  | TECH4_Institution_LANL [2%] | 6.4h | 41,048.96 |  | .50 | .50 | .50 |  |
| 274 | 1.5.4.4.7 | ship to BNL |  | 0.1w | 2020-05-27 | 2020-05-27 | 273 | 343.5d |  |  | MECHTECH4_Institution_LBNL [50%] | 2h | 2,260.26 |  | .35 | .35 | .35 |  |
| 275 | 1.5.4.5 | **Half detector Assembly Readout and Cooling Test at BNL** |  | 435.67d | 2019-06-04 | 2021-02-02 |  | 164d |  |  |  | 776h | 26,348.24 |  |  |  |  |  |
| 276 | 1.5.4.5.1 | Test Half Barrel #1 |  | 15d | 2020-12-16 | 2021-01-05 | 240 | 184d |  |  | MECHENG4_Institution_LBNL [20%]; POSTD_Institution_LBNL; STAFFPHYS_Institution_LBNL [20%] | 168h | 5,310.12 | LBNL | .35 | .35 | .35 |  |
| 277 | 1.5.4.5.2 | Test Half Barrel #2 |  | 15d | 2021-01-13 | 2021-02-02 | 246 | 12d | 0d |  | MECHENG4_Institution_LBNL [20%]; POSTD_Institution_LBNL; STAFFPHYS_Institution_LBNL [20%] | 168h | 5,310.12 | LBNL | .35 | .35 | .35 |  |
| 278 | 1.5.4.5.3 | Assemble & Test Cooling System at BNL |  | 20d | 2020-02-19 | 2020-03-17 | 256 | 394d |  |  | TECH4_Institution_MIT; SCI3_Institution_MIT [50%] | 240h | 15,728 | MIT | .35 | .35 | .35 |  |
| 279 | 1.5.4.5.4 | test RU at BNL |  | 2w | 2019-10-18 | 2019-10-31 | 147 | 492d |  |  | SCI3_Institution_LANL | 80h |  | LANL | .35 | .35 | .35 |  |
| 280 | 1.5.4.5.5 | test FELIX at BNL |  | 2w | 2019-11-18 | 2019-11-29 | 155 | 471d |  |  | SCI3_Institution_LANL | 80h |  | LANL | .35 | .35 | .35 |  |
| 281 | 1.5.4.5.6 | PS tests at BNL |  | 1w | 2019-06-04 | 2019-06-11 | 172 | 594.67d |  |  | POSTD_Institution_LBNL | 40h |  | LBNL | .35 | .35 | .35 |  |
| 282 | 1.5.4.6 | **Installation and Commissioning** |  | 497d | 2021-02-03 | 2022-12-29 |  | -333d | 0d |  |  | 2440h | 77,600.02 |  |  |  |  |  |
| 283 | 1.5.4.6.1 | Installation Prep |  | 10d | 2021-02-03 | 2021-02-16 | 277 | 12d | 0d | start no earlier than 2016-10-03 | Mech Tech; Physicist; Elec tech; STAFFPHYS_Institution_LBNL; POSTD_Institution_LBNL | 400h | 15,520 | ALL | .35 | .35 | .35 | DOE |
| 284 | 1.5.4.6.2 | Installation Review |  | 1d | 2021-02-17 | 2021-02-17 | 283 | 12d | 0d |  | Physicist; Mechanical Engineer; Electrical Engineer; STAFFPHYS_Institution_LBNL; POSTD_Institution_LBNL | 40h | 2,080 | ALL | .10 | .10 | .10 | DOE |
| 285 | 1.5.4.6.3 | Install FELIX |  | 2d | 2021-02-18 | 2021-02-19 | 284 | 12d | 0d |  | SCI3_Institution_LANL; PROF4_institution_LANL | 32h | 2,340.8 |  | .35 | .35 | .35 |  |
| 286 | 1.5.4.6.4 | Install Optical fibers |  | 1w | 2021-02-22 | 2021-02-26 | 285 | 12d | 0d |  | TECH4_Institution_LANL | 40h | 6,752 |  | .35 | .35 | .35 |  |
| 287 | 1.5.4.6.5 | Install RU |  | 2d | 2021-03-01 | 2021-03-02 | 286 | 12d | 0d |  | SCI3_Institution_LANL; PROF4_institution_LANL | 32h | 2,340.8 |  | .35 | .35 | .35 |  |
| 288 | 1.5.4.6.6 | Install Samtec Cables |  | 2d | 2021-03-03 | 2021-03-04 | 287 | 12d |  |  | TECH4_Institution_LANL | 16h | 2,700.8 |  | .35 | .35 | .35 |  |
| 289 | 1.5.4.6.7 | Install Half-Barrel 1 |  | 1mo | 2022-07-01 | 2022-07-28 | 288, 284, 15 | -333d | 0d |  | MECHTECH4_Institution_LBNL [50%]; STAFFPHYS_Institution_LBNL; MECHENG3_Institution_LBNL [50%]; POSTD_Institution_LBNL | 220h | 22,932.81 |  | .35 | .35 | .35 |  |
| 290 | 1.5.4.6.8 | Install Half-Barrel 2 |  | 1mo | 2022-07-29 | 2022-08-25 | 288, 289 | -333d | 0d |  | MECHTECH4_Institution_LBNL [50%]; STAFFPHYS_Institution_LBNL; MECHENG3_Institution_LBNL [50%]; POSTD_Institution_LBNL | 220h | 22,932.81 |  | .35 | .35 | .35 |  |
| 291 | 1.5.4.6.9 | Commissioning |  | 90d | 2022-08-26 | 2022-12-29 | 290 | -333d | 0d |  | Physicist [200%] | 1440h |  |  |  |  |  |  |
| 292 | 1.5.5 | Ready for beam | milestone | 0d | 2022-12-29 | 2022-12-29 | 291 | -333d | 0d |  |  |  |  |  |  |  |  |  |

Notes:
- 282: installatino by 6/2021
